# PFCMP.a1sim

Schedule from MS Project, 2002-01-02 to 2003-05-12, status date 2002-04-30, costs in pta, A marks actual dates.
kisko

## Calendars

- Estándar: Mon-Fri 08:00-14:00, 15:00-17:00; Sat-Sun off. Exceptions (off unless hours are given): 2002-03-19, 2002-03-28 to 2002-03-29, 2002-05-01, 2002-08-15, 2002-11-01, 2002-12-06, 2002-12-25, 2003-01-01, 2003-01-06, 2003-03-19, 2003-03-27 to 2003-03-28, 2003-05-01.

## Resources

| Resource | Unit | Rate | Cost per use |
| --- | --- | --- | --- |
| D proyecto |  | 10000 |  |
| Tecnico proceso |  | 8400 |  |
| Proy proceso 1 |  | 5200 |  |
| Proy proceso 2 |  | 5200 |  |
| Tecnico mecan 1 |  | 8100 |  |
| Tecnico mecan 2 |  | 8100 |  |
| Proy mecan 1 |  | 5000 |  |
| Proy mecan 2 |  | 5000 |  |
| Proy mecan 3 |  | 5000 |  |
| Tecnico elect |  | 8200 |  |
| Proy elect 1 |  | 5100 |  |
| Proy elect 2 |  | 5100 |  |
| Tecnico instrum |  | 8200 |  |
| Proy instrum 1 |  | 5100 |  |
| Proy instrum 2 |  | 5100 |  |
| Tecnico civil |  | 8000 |  |
| Proy civil 1 |  | 4500 |  |
| Proy civil 2 |  | 4500 |  |
| Mano de obra |  | 4000 |  |
| Hormigones | m3 | 10000 |  |
| Mov de tierras | m3 | 5000 |  |
| D facultativo |  | 5000 |  |
| Estructuras metalicas | Kg | 500 |  |
| Fibrocemento | m2 | 2500 |  |
| Montadores motogen |  | 4000 |  |
| Montadores tuberias |  | 4000 |  |
| Montadores elect e inst |  | 4000 |  |
| Operarios |  | 4000 |  |
| Personal de operación |  | 10000 |  |
| Consumos pruebas equipos |  | 16625 |  |
| Consumos pruebas hidraulicas |  | 25000 |  |
| Consumos prubas electricas |  | 16625 |  |
| Consumos pruebas instrumentación |  | 16625 |  |
| Ped ea |  |  | 3100000 |
| Ent pl ea |  |  | 9300000 |
| Pl def ea |  |  | 9300000 |
| Ent ea |  |  | 6200000 |
| Sat ea |  |  | 3100000 |
| Ped m |  |  | 19000000 |
| Ent pl m |  |  | 57000000 |
| Pl def m |  |  | 57000000 |
| Ent m |  |  | 38000000 |
| Sat m |  |  | 19000000 |
| Ped tya |  |  | 1600000 |
| Ent pl tya |  |  | 4800000 |
| Pl def tya |  |  | 4800000 |
| Ent tya |  |  | 3200000 |
| Sat tya |  |  | 1600000 |
| Ped ee |  |  | 3900000 |
| Ent pl ee |  |  | 11700000 |
| Pl def ee |  |  | 11700000 |
| Ent ee |  |  | 7800000 |
| Sat ee |  |  | 3900000 |
| Ped iysc |  |  | 1600000 |
| Ent pl iysc |  |  | 4800000 |
| Pl def iysc |  |  | 4800000 |
| Ent iysc |  |  | 3200000 |
| Sat iysc |  |  | 1600000 |
| Otros gastos | up | 10000 |  |

## Schedule

| ID | WBS | Task | Duration | Start | Finish | Predecessors | Complete | Remaining | Baseline start | Baseline finish | Baseline duration | Total slack | Free slack | Resources | Work | Actual work | Cost | Baseline cost | Actual cost |
| --- | --- | --- | --- | --- | --- | --- | --- | --- | --- | --- | --- | --- | --- | --- | --- | --- | --- | --- | --- |
| 1 | 1 | **PROYECTO** | 340d | 2002-01-02 A | 2003-05-12 |  | 17% | 282.62d | 2002-01-02 | 2003-05-05 | 335d | 0d |  |  | 30263.8h | 3632h | 484,278,200 | 484,200,700 | 25,427,800 |
| 2 | 1.1 | Dirección de proyecto 1 | 340d | 2002-01-02 A | 2003-05-12 |  | 24% | 258d | 2002-01-02 | 2003-05-05 | 335d | 0d |  | D proyecto [75%] | 1215h | 292h | 12,150,000 | 11,550,000 | 2,920,000 |
| 3 | 1.2 | **INGENIERÍA** | 75d | 2002-01-02 A | 2002-04-19 A |  | 100% |  | 2002-01-02 | 2002-04-12 | 70d |  |  |  | 2075h | 2075h | 12,764,000 | 11,486,500 | 12,764,000 |
| 4 | 1.2.1 | Ingeniería Básica | 30d | 2002-01-02 A | 2002-02-12 A |  | 100% |  | 2002-01-02 | 2002-02-12 | 30d |  |  | Tecnico proceso [87.5%]; Proy proceso 1; Proy proceso 2 [87.5%] | 660h | 660h | 4,104,000 | 4,104,000 | 4,104,000 |
| 5 | 1.2.2 | Ingeniería Básica del edificio | 20d | 2002-02-13 A | 2002-03-12 A | 4 | 100% |  | 2002-02-13 | 2002-03-05 | 15d |  |  | Tecnico civil; Proy civil 1; Proy civil 2 [37.5%] | 380h | 380h | 2,270,000 | 1,702,500 | 2,270,000 |
| 6 | 1.2.3 | Ingeniería de proceso | 45d | 2002-02-13 A | 2002-04-19 A | 4 | 100% |  | 2002-02-13 | 2002-04-12 | 40d |  |  | Tecnico proceso [87.5%]; Proy proceso 1; Proy proceso 2 | 1035h | 1035h | 6,390,000 | 5,680,000 | 6,390,000 |
| 7 | 1.3 | **INGENIERÍA DE DETALLE** | 105d | 2002-03-13 A | 2002-08-12 |  | 23% | 80.8d | 2002-03-06 | 2002-08-05 | 105d | 185d |  |  | 5160h | 939h | 31,784,000 | 31,584,000 | 5,663,800 |
| 8 | 1.3.1 | Ing. Detalle estructuras y arquitectura | 30d | 2002-04-15 A | 2002-05-27 | 5 | 40% | 18d | 2002-04-08 | 2002-05-20 | 30d | 140d | 0d | Tecnico civil [87.5%]; Proy civil 1; Proy civil 2 [62.5%] | 600h | 240h | 3,435,000 | 3,435,000 | 1,374,000 |
| 9 | 1.3.2 | Ing. Detalle motogeneradores (especs) | 30d | 2002-04-22 A | 2002-06-03 | 6 | 23% | 23d | 2002-04-15 | 2002-05-27 | 30d | 0d |  | Tecnico mecan 1 [62.5%]; Proy mecan 1 | 390h | 91h | 2,415,000 | 2,415,000 | 563,500 |
| 10 | 1.3.3 | Ing. Detalle tuberías y equipos auxiliares | 50d | 2002-06-04 | 2002-08-12 | 6 |  |  | 2002-05-28 | 2002-08-05 | 50d | 0d |  | Tecnico mecan 1; Tecnico mecan 2; Proy mecan 1; Proy mecan 2; Proy mecan 3 [75%] | 1900h |  | 11,980,000 | 11,980,000 |  |
| 11 | 1.3.4 | Ing. Detalle eléctrica | 50d | 2002-04-22 A | 2002-07-01 | 6 | 14% | 43d | 2002-04-15 | 2002-06-10 | 40d | 60d | 0d | Tecnico elect; Proy elect 1; Proy elect 2 [87.5%] | 920h | 161h | 5,684,000 | 5,684,000 | 994,700 |
| 12 | 1.3.5 | Ing. Detalle instrumentación y control | 50d | 2002-04-22 A | 2002-07-01 | 6 | 14% | 43d | 2002-04-15 | 2002-06-24 | 50d | 70d | 0d | Tecnico instrum [87.5%]; Proy instrum 1; Proy instrum 2 [75%] | 1050h | 147h | 6,440,000 | 6,440,000 | 901,600 |
| 13 | 1.3.6 | Ing. Detalle explanación y cimentaciones | 20d | 2002-03-13 A | 2002-04-12 A | 5 | 100% |  | 2002-03-06 | 2002-04-05 | 20d |  |  | Tecnico civil [50%]; Proy civil 1; Proy civil 2 [37.5%]; Otros gastos [20 up] | 300h | 300h | 1,830,000 | 1,630,000 | 1,830,000 |
| 14 | 1.4 | **SUMINISTRO** | 125d | 2002-06-04 | 2002-11-27 |  |  |  | 2002-05-28 | 2002-11-06 | 115d | 0d |  |  |  |  | 292,000,000 | 294,000,000 |  |
| 15 | 1.4.1 | Suministro equipos auxiliares | 40d | 2002-08-13 | 2002-10-08 | 10 |  |  | 2002-08-06 | 2002-10-01 | 40d | 10d | 0d | Ped ea |  |  | 3,100,000 | 3,100,000 |  |
| 16 | 1.4.2 | pago entrega planos ea | 1d | 2002-08-30 | 2002-08-30 | 15SS+3% |  |  | 2002-08-23 | 2002-08-23 | 1d | 172d |  | Ent pl ea |  |  | 9,300,000 | 9,300,000 |  |
| 17 | 1.4.3 | pago planos definitivos ea | 1d | 2002-09-11 | 2002-09-11 | 15SS+20d |  |  | 2002-09-04 | 2002-09-04 | 1d | 164d |  | Pl def ea |  |  | 9,300,000 | 9,300,000 |  |
| 18 | 1.4.4 | pago entrega ea | 1d | 2002-10-08 | 2002-10-08 | 15FF |  |  | 2002-10-01 | 2002-10-01 | 1d | 145d |  | Ent ea |  |  | 6,200,000 | 6,200,000 |  |
| 19 | 1.4.5 | pago satisfactorio ea | 1d | 2002-10-29 | 2002-10-29 | 15FF+15d |  |  | 2002-10-22 | 2002-10-22 | 1d | 130d |  | Sat ea |  |  | 3,100,000 | 3,100,000 |  |
| 20 | 1.4.6 | Suministro motogeneradores | 80d | 2002-06-04 | 2002-09-24 | 9 |  |  | 2002-05-28 | 2002-09-17 | 80d | 0d |  | Ped m |  |  | 19,000,000 | 19,000,000 |  |
| 21 | 1.4.7 | pago entrega planos m | 1d | 2002-07-08 | 2002-07-08 | 20SS+3% |  |  | 2002-07-01 | 2002-07-01 | 1d | 210d |  | Ent pl m |  |  | 57,000,000 | 57,000,000 |  |
| 22 | 1.4.8 | pago planos definitivos m | 1d | 2002-07-30 | 2002-07-30 | 20SS+40d |  |  | 2002-07-23 | 2002-07-23 | 1d | 194d |  | Pl def m |  |  | 57,000,000 | 57,000,000 |  |
| 23 | 1.4.9 | pago entrega m | 1d | 2002-09-24 | 2002-09-24 | 20FF |  |  | 2002-09-17 | 2002-09-17 | 1d | 155d |  | Ent m |  |  | 38,000,000 | 38,000,000 |  |
| 24 | 1.4.10 | pago satisfactorio m | 1d | 2002-10-15 | 2002-10-15 | 20FF+15d |  |  | 2002-10-08 | 2002-10-08 | 1d | 140d |  | Sat m |  |  | 19,000,000 | 19,000,000 |  |
| 25 | 1.4.11 | Suministro tuberías y accesorios | 50d | 2002-08-13 | 2002-10-22 | 10 |  |  | 2002-08-06 | 2002-10-15 | 50d | 0d |  | Ped tya |  |  | 1,600,000 | 1,600,000 |  |
| 26 | 1.4.12 | pago entrega planos ta | 1d | 2002-09-04 | 2002-09-04 | 25SS+3% |  |  | 2002-08-28 | 2002-08-28 | 1d | 169d |  | Ent pl tya |  |  | 4,800,000 | 4,800,000 |  |
| 27 | 1.4.13 | pago planos definitivos ta | 1d | 2002-09-18 | 2002-09-18 | 25SS+25d |  |  | 2002-09-11 | 2002-09-11 | 1d | 159d |  | Pl def tya |  |  | 4,800,000 | 4,800,000 |  |
| 28 | 1.4.14 | pago entrega ta | 1d | 2002-10-22 | 2002-10-22 | 25FF |  |  | 2002-10-15 | 2002-10-15 | 1d | 135d |  | Ent tya |  |  | 3,200,000 | 3,200,000 |  |
| 29 | 1.4.15 | pago satisfactorio ta | 1d | 2002-11-13 | 2002-11-13 | 25FF+15d |  |  | 2002-11-06 | 2002-11-06 | 1d | 120d |  | Sat tya |  |  | 1,600,000 | 1,600,000 |  |
| 30 | 1.4.16 | Suministro equipos eléctricos | 60d | 2002-08-13 | 2002-11-06 | 11FS+30d |  |  | 2002-06-11 | 2002-09-03 | 60d | 30d | 0d | Ped ee |  |  | 3,900,000 | 4,100,000 |  |
| 31 | 1.4.17 | pago entrega planos ee | 1d | 2002-09-09 | 2002-09-09 | 30SS+3% |  |  | 2002-07-09 | 2002-07-09 | 1d | 166d |  | Ent pl ee |  |  | 11,700,000 | 12,300,000 |  |
| 32 | 1.4.18 | pago planos definitivos ee | 1d | 2002-09-25 | 2002-09-25 | 30SS+30d |  |  | 2002-07-23 | 2002-07-23 | 1d | 154d |  | Pl def ee |  |  | 11,700,000 | 12,300,000 |  |
| 33 | 1.4.19 | pago entrega ee | 1d | 2002-11-06 | 2002-11-06 | 30FF |  |  | 2002-09-03 | 2002-09-03 | 1d | 125d |  | Ent ee |  |  | 7,800,000 | 8,200,000 |  |
| 34 | 1.4.20 | pago satisfactorio ee | 1d | 2002-11-27 | 2002-11-27 | 30FF+15d |  |  | 2002-09-24 | 2002-09-24 | 1d | 110d |  | Sat ee |  |  | 3,900,000 | 4,100,000 |  |
| 35 | 1.4.21 | Suministro instrumentación y sist. Control | 50d | 2002-07-02 | 2002-09-10 | 12 |  |  | 2002-06-25 | 2002-09-03 | 50d | 70d | 0d | Ped iysc |  |  | 1,600,000 | 1,600,000 |  |
| 36 | 1.4.22 | pago entrega planos isc | 1d | 2002-07-23 | 2002-07-23 | 35SS+3% |  |  | 2002-07-16 | 2002-07-16 | 1d | 199d |  | Ent pl iysc |  |  | 4,800,000 | 4,800,000 |  |
| 37 | 1.4.23 | pago planos definitivos isc | 1d | 2002-08-06 | 2002-08-06 | 35SS+25d |  |  | 2002-07-30 | 2002-07-30 | 1d | 189d |  | Pl def iysc |  |  | 4,800,000 | 4,800,000 |  |
| 38 | 1.4.24 | pago entrega isc | 1d | 2002-09-10 | 2002-09-10 | 35FF |  |  | 2002-09-03 | 2002-09-03 | 1d | 165d |  | Ent iysc |  |  | 3,200,000 | 3,200,000 |  |
| 39 | 1.4.25 | pago satisfactorio isc | 1d | 2002-10-01 | 2002-10-01 | 35FF+15d |  |  | 2002-09-24 | 2002-09-24 | 1d | 150d |  | Sat iysc |  |  | 1,600,000 | 1,600,000 |  |

| ID | WBS | Task | Duration | Start | Finish | Predecessors | Complete | Remaining | Baseline start | Baseline finish | Baseline duration | Total slack | Free slack | Resources | Work | Actual work | Cost | Baseline cost | Actual cost |
| --- | --- | --- | --- | --- | --- | --- | --- | --- | --- | --- | --- | --- | --- | --- | --- | --- | --- | --- | --- |
| 40 | 1.5 | **CONSTRUCCION Y MONTAJE** | 215d | 2002-04-15 A | 2003-02-18 |  | 6% | 203.14d | 2002-04-08 | 2003-02-11 | 215d | 55d |  |  | 15043.8h | 326h | 85,595,200 | 85,595,200 | 4,080,000 |
| 41 | 1.5.1 | Dirección de construcción | 215d | 2002-04-15 A | 2003-02-18 | 42SS | 6% | 203d | 2002-04-08 | 2003-02-11 | 215d | 55d |  | D facultativo | 1720h | 96h | 8,600,000 | 8,600,000 | 480,000 |
| 42 | 1.5.2 | Explanación y construcción cimentaciones | 30d | 2002-04-15 A | 2002-05-27 | 13 | 40% | 18d | 2002-04-08 | 2002-05-20 | 30d | 85d | 0d | Mano de obra [239.6%]; Hormigones [480 m3]; Mov de tierras [380 m3] | 575h | 230h | 9,000,000 | 9,000,000 | 3,600,000 |
| 43 | 1.5.3 | Construcción estructura edificio | 50d | 2002-05-28 | 2002-08-05 | 8, 42 |  |  | 2002-05-21 | 2002-07-29 | 50d | 140d | 0d | Mano de obra [500%]; Estructuras metalicas [24000 Kg] | 2000h |  | 20,000,000 | 20,000,000 |  |
| 44 | 1.5.4 | Cerramientos y acabados | 40d | 2002-08-06 | 2002-10-01 | 43 |  |  | 2002-07-30 | 2002-09-24 | 40d | 140d |  | Mano de obra [234%]; Fibrocemento [2000 m2] | 748.8h |  | 7,995,200 | 7,995,200 |  |
| 45 | 1.5.5 | Montaje motogeneradores | 20d | 2002-09-25 | 2002-10-22 | 20, 42 |  |  | 2002-09-18 | 2002-10-15 | 20d | 0d |  | Montadores motogen [937.5%] | 1500h |  | 6,000,000 | 6,000,000 |  |
| 46 | 1.5.6 | Montaje tuberías y equipos auxiliares | 40d | 2002-10-23 | 2002-12-19 | 45, 15, 25 |  |  | 2002-10-16 | 2002-12-12 | 40d | 0d |  | Montadores tuberias [1250%] | 4000h |  | 16,000,000 | 16,000,000 |  |
| 47 | 1.5.7 | Montaje electricidad e instrumentación | 40d | 2002-12-20 | 2003-02-18 | 30, 35, 46 |  |  | 2002-12-13 | 2003-02-11 | 40d | 0d |  | Montadores elect e inst [1406.2%] | 4500h |  | 18,000,000 | 18,000,000 |  |
| 48 | 1.6 | **PRUEBAS Y PUESTA EN SERVICIO** | 95d | 2002-12-20 | 2003-05-12 |  |  |  | 2002-12-13 | 2003-05-05 | 95d | 0d |  |  | 6770h |  | 49,985,000 | 49,985,000 |  |
| 49 | 1.6.1 | Pruebas equipos en vacío | 15d | 2003-01-22 | 2003-02-11 | 50, 45 |  |  | 2003-01-15 | 2003-02-04 | 15d | 20d |  | Consumos pruebas equipos; Operarios [625%] | 870h |  | 4,995,000 | 4,995,000 |  |
| 50 | 1.6.2 | Pruebas hidraúlicas tuberías y equipos | 20d | 2002-12-20 | 2003-01-21 | 46 |  |  | 2002-12-13 | 2003-01-14 | 20d | 20d | 0d | Consumos pruebas hidraulicas; Operarios [937.5%] | 1660h |  | 10,000,000 | 10,000,000 |  |
| 51 | 1.6.3 | Pruebas eléctricas | 15d | 2003-02-19 | 2003-03-11 | 47 |  |  | 2003-02-12 | 2003-03-04 | 15d | 0d |  | Consumos prubas electricas; Operarios [625%] | 870h |  | 4,995,000 | 4,995,000 |  |
| 52 | 1.6.4 | Pruebas instrumentos y sist control | 15d | 2003-02-19 | 2003-03-11 | 47 |  |  | 2003-02-12 | 2003-03-04 | 15d | 0d |  | Consumos pruebas instrumentación; Operarios [625%] | 870h |  | 4,995,000 | 4,995,000 |  |
| 53 | 1.6.5 | Puesta en marcha | 20d | 2003-03-12 | 2003-04-11 | 49, 51, 52 |  |  | 2003-03-05 | 2003-04-04 | 20d | 0d |  | Personal de operación [625%] | 1000h |  | 10,000,000 | 10,000,000 |  |
| 54 | 1.6.6 | Puesta en operación | 10d | 2003-04-14 | 2003-04-25 | 53 |  |  | 2003-04-07 | 2003-04-18 | 10d | 0d |  | Personal de operación [875%] | 700h |  | 7,000,000 | 7,000,000 |  |
| 55 | 1.6.7 | Garantías y recepción | 10d | 2003-04-28 | 2003-05-12 | 54, 44 |  |  | 2003-04-21 | 2003-05-05 | 10d | 0d |  | Personal de operación [1000%] | 800h |  | 8,000,000 | 8,000,000 |  |
