# PFCMP.a3sim

Schedule from MS Project, 2002-01-02 to 2003-05-15, status date 2002-10-31, costs in pta, A marks actual dates.
kisko

## Calendars

- Estándar: Mon-Fri 08:00-14:00, 15:00-17:00; Sat-Sun off. Exceptions (off unless hours are given): 2002-03-19, 2002-03-28 to 2002-03-29, 2002-05-01, 2002-08-15, 2002-11-01, 2002-12-06, 2002-12-25, 2003-01-01, 2003-01-06, 2003-03-19, 2003-03-27 to 2003-03-28, 2003-05-01.

## Resources

| Resource | Unit | Rate | Cost per use |
| --- | --- | --- | --- |
| D proyecto |  | 10000 |  |
| Tecnico proceso |  | 8400 |  |
| Proy proceso 1 |  | 5200 |  |
| Proy proceso 2 |  | 5200 |  |
| Tecnico mecan 1 |  | 8100 |  |
| Tecnico mecan 2 |  | 8100 |  |
| Proy mecan 1 |  | 5000 |  |
| Proy mecan 2 |  | 5000 |  |
| Proy mecan 3 |  | 5000 |  |
| Tecnico elect |  | 8200 |  |
| Proy elect 1 |  | 5100 |  |
| Proy elect 2 |  | 5100 |  |
| Tecnico instrum |  | 8200 |  |
| Proy instrum 1 |  | 5100 |  |
| Proy instrum 2 |  | 5100 |  |
| Tecnico civil |  | 8000 |  |
| Proy civil 1 |  | 4500 |  |
| Proy civil 2 |  | 4500 |  |
| Mano de obra |  | 4000 |  |
| Hormigones | m3 | 10000 |  |
| Mov de tierras | m3 | 5000 |  |
| D facultativo |  | 5000 |  |
| Estructuras metalicas | Kg | 500 |  |
| Fibrocemento | m2 | 2500 |  |
| Montadores motogen |  | 4000 |  |
| Montadores tuberias |  | 4000 |  |
| Montadores elect e inst |  | 4000 |  |
| Operarios |  | 4000 |  |
| Personal de operación |  | 10000 |  |
| Consumos pruebas equipos |  | 16625 |  |
| Consumos pruebas hidraulicas |  | 25000 |  |
| Consumos prubas electricas |  | 16625 |  |
| Consumos pruebas instrumentación |  | 16625 |  |
| Ped ea |  |  | 3100000 |
| Ent pl ea |  |  | 9300000 |
| Pl def ea |  |  | 9300000 |
| Ent ea |  |  | 6200000 |
| Sat ea |  |  | 3100000 |
| Ped m |  |  | 19000000 |
| Ent pl m |  |  | 57000000 |
| Pl def m |  |  | 57000000 |
| Ent m |  |  | 38000000 |
| Sat m |  |  | 19000000 |
| Ped tya |  |  | 1600000 |
| Ent pl tya |  |  | 4800000 |
| Pl def tya |  |  | 4800000 |
| Ent tya |  |  | 3200000 |
| Sat tya |  |  | 2000000 |
| Ped ee |  |  | 3900000 |
| Ent pl ee |  |  | 11700000 |
| Pl def ee |  |  | 11700000 |
| Ent ee |  |  | 7800000 |
| Sat ee |  |  | 3900000 |
| Ped iysc |  |  | 1600000 |
| Ent pl iysc |  |  | 4800000 |
| Pl def iysc |  |  | 4800000 |
| Ent iysc |  |  | 3200000 |
| Sat iysc |  |  | 1600000 |
| Otros gastos | up | 10000 |  |
| Mont Mot bis |  | 4500 |  |
| Mont tub bis |  | 4500 |  |
| Mont elect bis |  | 4500 |  |

## Schedule

| ID | WBS | Task | Duration | Start | Finish | Predecessors | Complete | Remaining | Baseline start | Baseline finish | Baseline duration | Total slack | Free slack | Constraint | Resources | Work | Actual work | Cost | Baseline cost | Actual cost |
| --- | --- | --- | --- | --- | --- | --- | --- | --- | --- | --- | --- | --- | --- | --- | --- | --- | --- | --- | --- | --- |
| 1 | 1 | **PROYECTO** | 342.05d | 2002-01-02 A | 2003-05-15 |  | 72% | 94.2d | 2002-01-02 | 2003-05-05 | 335d | 0d |  |  |  | 32167.8h | 14855.7h | 496,846,532.07 | 484,200,700 | 382,659,960 |
| 2 | 1.1 | Dirección de proyecto 1 | 342d | 2002-01-02 A | 2003-05-14 |  | 62% | 130d | 2002-01-02 | 2003-05-05 | 335d | 0.05d |  |  | D proyecto [75%] | 1247h | 1072h | 12,470,000 | 11,550,000 | 10,720,000 |
| 3 | 1.2 | **INGENIERÍA** | 75d | 2002-01-02 A | 2002-04-19 A |  | 100% |  | 2002-01-02 | 2002-04-12 | 70d |  |  |  |  | 2075h | 2075h | 12,764,000 | 11,486,500 | 12,764,000 |
| 4 | 1.2.1 | Ingeniería Básica | 30d | 2002-01-02 A | 2002-02-12 A |  | 100% |  | 2002-01-02 | 2002-02-12 | 30d |  |  |  | Tecnico proceso [87.5%]; Proy proceso 1; Proy proceso 2 [87.5%] | 660h | 660h | 4,104,000 | 4,104,000 | 4,104,000 |
| 5 | 1.2.2 | Ingeniería Básica del edificio | 20d | 2002-02-13 A | 2002-03-12 A | 4 | 100% |  | 2002-02-13 | 2002-03-05 | 15d |  |  |  | Tecnico civil; Proy civil 1; Proy civil 2 [37.5%] | 380h | 380h | 2,270,000 | 1,702,500 | 2,270,000 |
| 6 | 1.2.3 | Ingeniería de proceso | 45d | 2002-02-13 A | 2002-04-19 A | 4 | 100% |  | 2002-02-13 | 2002-04-12 | 40d |  |  |  | Tecnico proceso [87.5%]; Proy proceso 1; Proy proceso 2 | 1035h | 1035h | 6,390,000 | 5,680,000 | 6,390,000 |
| 7 | 1.3 | **INGENIERÍA DE DETALLE** | 105d | 2002-03-13 A | 2002-08-12 A |  | 100% |  | 2002-03-06 | 2002-08-05 | 105d |  |  |  |  | 5160h | 5160h | 31,784,000 | 31,584,000 | 31,784,000 |
| 8 | 1.3.1 | Ing. Detalle estructuras y arquitectura | 30d | 2002-04-15 A | 2002-05-27 A | 5 | 100% |  | 2002-04-08 | 2002-05-20 | 30d |  |  |  | Tecnico civil [87.5%]; Proy civil 1; Proy civil 2 [62.5%] | 600h | 600h | 3,435,000 | 3,435,000 | 3,435,000 |
| 9 | 1.3.2 | Ing. Detalle motogeneradores (especs) | 30d | 2002-04-22 A | 2002-06-03 A | 6 | 100% |  | 2002-04-15 | 2002-05-27 | 30d |  |  |  | Tecnico mecan 1 [62.5%]; Proy mecan 1 | 390h | 390h | 2,415,000 | 2,415,000 | 2,415,000 |
| 10 | 1.3.3 | Ing. Detalle tuberías y equipos auxiliares | 50d | 2002-06-04 A | 2002-08-12 A | 6 | 100% |  | 2002-05-28 | 2002-08-05 | 50d |  |  |  | Tecnico mecan 1; Tecnico mecan 2; Proy mecan 1; Proy mecan 2; Proy mecan 3 [75%] | 1900h | 1900h | 11,980,000 | 11,980,000 | 11,980,000 |
| 11 | 1.3.4 | Ing. Detalle eléctrica | 50d | 2002-04-22 A | 2002-07-01 A | 6 | 100% |  | 2002-04-15 | 2002-06-10 | 40d |  |  |  | Tecnico elect; Proy elect 1; Proy elect 2 [87.5%] | 920h | 920h | 5,684,000 | 5,684,000 | 5,684,000 |
| 12 | 1.3.5 | Ing. Detalle instrumentación y control | 50d | 2002-04-22 A | 2002-07-01 A | 6 | 100% |  | 2002-04-15 | 2002-06-24 | 50d |  |  |  | Tecnico instrum [87.5%]; Proy instrum 1; Proy instrum 2 [75%] | 1050h | 1050h | 6,440,000 | 6,440,000 | 6,440,000 |
| 13 | 1.3.6 | Ing. Detalle explanación y cimentaciones | 20d | 2002-03-13 A | 2002-04-12 A | 5 | 100% |  | 2002-03-06 | 2002-04-05 | 20d |  |  |  | Tecnico civil [50%]; Proy civil 1; Proy civil 2 [37.5%]; Otros gastos [20 up] | 300h | 300h | 1,830,000 | 1,630,000 | 1,830,000 |
| 14 | 1.4 | **SUMINISTRO** | 130.63d | 2002-06-04 A | 2002-12-05 |  | 95% | 6.59d | 2002-05-28 | 2002-11-06 | 115d | 106.42d |  |  |  |  |  | 292,400,000 | 294,000,000 | 275,500,000 |
| 15 | 1.4.1 | Suministro equipos auxiliares | 40d | 2002-08-13 A | 2002-10-08 A | 10 | 100% |  | 2002-08-06 | 2002-10-01 | 40d |  |  |  | Ped ea |  |  | 3,100,000 | 3,100,000 | 3,100,000 |
| 16 | 1.4.2 | pago entrega planos ea | 1d | 2002-08-30 A | 2002-08-30 A | 15SS+3% | 100% |  | 2002-08-23 | 2002-08-23 | 1d |  |  |  | Ent pl ea |  |  | 9,300,000 | 9,300,000 | 9,300,000 |
| 17 | 1.4.3 | pago planos definitivos ea | 1d | 2002-09-11 A | 2002-09-11 A | 15SS+20d | 100% |  | 2002-09-04 | 2002-09-04 | 1d |  |  |  | Pl def ea |  |  | 9,300,000 | 9,300,000 | 9,300,000 |
| 18 | 1.4.4 | pago entrega ea | 1d | 2002-10-08 A | 2002-10-08 A | 15FF | 100% |  | 2002-10-01 | 2002-10-01 | 1d |  |  |  | Ent ea |  |  | 6,200,000 | 6,200,000 | 6,200,000 |
| 19 | 1.4.5 | pago satisfactorio ea | 1d | 2002-10-29 A | 2002-10-29 A | 15FF+15d | 100% |  | 2002-10-22 | 2002-10-22 | 1d |  |  |  | Sat ea |  |  | 3,100,000 | 3,100,000 | 3,100,000 |
| 20 | 1.4.6 | Suministro motogeneradores | 90d | 2002-06-04 A | 2002-10-08 A | 9 | 100% |  | 2002-05-28 | 2002-09-17 | 80d |  |  |  | Ped m |  |  | 19,000,000 | 19,000,000 | 19,000,000 |
| 21 | 1.4.7 | pago entrega planos m | 1d | 2002-07-08 A | 2002-07-08 A | 20SS+3% | 100% |  | 2002-07-01 | 2002-07-01 | 1d |  |  |  | Ent pl m |  |  | 57,000,000 | 57,000,000 | 57,000,000 |
| 22 | 1.4.8 | pago planos definitivos m | 1d | 2002-08-06 A | 2002-08-06 A | 20SS+5% | 100% |  | 2002-07-23 | 2002-07-23 | 1d |  |  |  | Pl def m |  |  | 57,000,000 | 57,000,000 | 57,000,000 |
| 23 | 1.4.9 | pago entrega m | 1d | 2002-10-08 A | 2002-10-08 A | 20FF | 100% |  | 2002-09-17 | 2002-09-17 | 1d |  |  |  | Ent m |  |  | 38,000,000 | 38,000,000 | 38,000,000 |
| 24 | 1.4.10 | pago satisfactorio m | 1d | 2002-10-29 A | 2002-10-29 A | 20FF+15d | 100% |  | 2002-10-08 | 2002-10-08 | 1d |  |  |  | Sat m |  |  | 19,000,000 | 19,000,000 | 19,000,000 |
| 25 | 1.4.11 | Suministro tuberías y accesorios | 50d | 2002-09-04 A | 2002-11-14 | 10 | 83% | 8.63d | 2002-08-06 | 2002-10-15 | 50d | 0d |  | as late as possible | Ped tya |  |  | 1,600,000 | 1,600,000 | 1,600,000 |
| 26 | 1.4.12 | pago entrega planos ta | 1d | 2002-09-25 A | 2002-09-26 A | 25SS+3% | 100% |  | 2002-08-28 | 2002-08-28 | 1d |  |  |  | Ent pl tya |  |  | 4,800,000 | 4,800,000 | 4,800,000 |
| 27 | 1.4.13 | pago planos definitivos ta | 1d | 2002-10-09 A | 2002-10-10 A | 25SS+25d | 100% |  | 2002-09-11 | 2002-09-11 | 1d |  |  |  | Pl def tya |  |  | 4,800,000 | 4,800,000 | 4,800,000 |
| 28 | 1.4.14 | pago entrega ta | 1d | 2002-11-13 | 2002-11-14 | 25FF |  |  | 2002-10-15 | 2002-10-15 | 1d | 121.42d |  |  | Ent tya |  |  | 3,200,000 | 3,200,000 |  |
| 29 | 1.4.15 | pago satisfactorio ta | 1d | 2002-12-04 | 2002-12-05 | 25FF+15d |  |  | 2002-11-06 | 2002-11-06 | 1d | 106.42d |  |  | Sat tya |  |  | 2,000,000 | 1,600,000 |  |
| 30 | 1.4.16 | Suministro equipos eléctricos | 60d | 2002-08-13 A | 2002-11-06 | 11FS+30d | 95% | 3d | 2002-06-11 | 2002-09-03 | 60d | 38.96d | 0d |  | Ped ee |  |  | 3,900,000 | 4,100,000 | 3,900,000 |
| 31 | 1.4.17 | pago entrega planos ee | 1d | 2002-09-09 A | 2002-09-09 A | 30SS+3% | 100% |  | 2002-07-09 | 2002-07-09 | 1d |  |  |  | Ent pl ee |  |  | 11,700,000 | 12,300,000 | 11,700,000 |
| 32 | 1.4.18 | pago planos definitivos ee | 1d | 2002-09-25 A | 2002-09-25 A | 30SS+30d | 100% |  | 2002-07-23 | 2002-07-23 | 1d |  |  |  | Pl def ee |  |  | 11,700,000 | 12,300,000 | 11,700,000 |
| 33 | 1.4.19 | pago entrega ee | 1d | 2002-11-06 | 2002-11-06 | 30FF |  |  | 2002-09-03 | 2002-09-03 | 1d | 127.05d |  |  | Ent ee |  |  | 7,800,000 | 8,200,000 |  |
| 34 | 1.4.20 | pago satisfactorio ee | 1d | 2002-11-27 | 2002-11-27 | 30FF+15d |  |  | 2002-09-24 | 2002-09-24 | 1d | 112.05d |  |  | Sat ee |  |  | 3,900,000 | 4,100,000 |  |
| 35 | 1.4.21 | Suministro instrumentación y sist. Control | 50d | 2002-07-02 A | 2002-09-10 A | 12 | 100% |  | 2002-06-25 | 2002-09-03 | 50d |  |  |  | Ped iysc |  |  | 1,600,000 | 1,600,000 | 1,600,000 |
| 36 | 1.4.22 | pago entrega planos isc | 1d | 2002-07-23 A | 2002-07-23 A | 35SS+3% | 100% |  | 2002-07-16 | 2002-07-16 | 1d |  |  |  | Ent pl iysc |  |  | 4,800,000 | 4,800,000 | 4,800,000 |
| 37 | 1.4.23 | pago planos definitivos isc | 1d | 2002-08-06 A | 2002-08-06 A | 35SS+25d | 100% |  | 2002-07-30 | 2002-07-30 | 1d |  |  |  | Pl def iysc |  |  | 4,800,000 | 4,800,000 | 4,800,000 |
| 38 | 1.4.24 | pago entrega isc | 1d | 2002-09-10 A | 2002-09-10 A | 35FF | 100% |  | 2002-09-03 | 2002-09-03 | 1d |  |  |  | Ent iysc |  |  | 3,200,000 | 3,200,000 | 3,200,000 |
| 39 | 1.4.25 | pago satisfactorio isc | 1d | 2002-10-01 A | 2002-10-01 A | 35FF+15d | 100% |  | 2002-09-24 | 2002-09-24 | 1d |  |  |  | Sat iysc |  |  | 1,600,000 | 1,600,000 | 1,600,000 |

| ID | WBS | Task | Duration | Start | Finish | Predecessors | Complete | Remaining | Baseline start | Baseline finish | Baseline duration | Total slack | Free slack | Resources | Work | Actual work | Cost | Baseline cost | Actual cost |
| --- | --- | --- | --- | --- | --- | --- | --- | --- | --- | --- | --- | --- | --- | --- | --- | --- | --- | --- | --- |
| 40 | 1.5 | **CONSTRUCCION Y MONTAJE** | 218d | 2002-04-15 A | 2003-02-21 |  | 62% | 82.48d | 2002-04-08 | 2003-02-11 | 215d | 54.05d |  |  | 16915.8h | 6548.74h | 97,443,532.07 | 85,595,200 | 51,891,960 |
| 41 | 1.5.1 | Dirección de construcción | 218d | 2002-04-15 A | 2003-02-21 | 42SS | 65% | 76d | 2002-04-08 | 2003-02-11 | 215d | 54.05d |  | D facultativo | 1744h | 1136h | 8,720,000 | 8,600,000 | 5,680,000 |
| 42 | 1.5.2 | Explanación y construcción cimentaciones | 45d | 2002-04-15 A | 2002-06-17 A | 13 | 100% |  | 2002-04-08 | 2002-05-20 | 30d |  |  | Mano de obra [239.6%]; Hormigones [480 m3]; Mov de tierras [380 m3] | 862.5h | 862.5h | 10,150,000 | 9,000,000 | 10,150,000 |
| 43 | 1.5.3 | Construcción estructura edificio | 65d | 2002-06-18 A | 2002-10-08 A | 8, 42 | 100% |  | 2002-05-21 | 2002-07-29 | 50d |  |  | Mano de obra [500%]; Estructuras metalicas [31200 Kg] | 2600h | 2600h | 26,000,000 | 20,000,000 | 26,000,000 |
| 44 | 1.5.4 | Cerramientos y acabados | 40d | 2002-10-09 A | 2002-12-04 | 43 | 43% | 23d | 2002-07-30 | 2002-09-24 | 40d | 97.05d |  | Mano de obra [234%]; Fibrocemento [2000 m2] | 748.8h | 318.24h | 7,995,200 | 7,995,200 | 3,397,960 |
| 45 | 1.5.5 | Montaje motogeneradores | 25.63d | 2002-10-09 A | 2002-11-14 | 20, 42 | 66% | 8.63d | 2002-09-18 | 2002-10-15 | 20d | 0d |  | Montadores motogen [1000%]; Mont Mot bis [200%] | 2460.48h | 1632h | 10,046,960 | 6,000,000 | 6,664,000 |
| 46 | 1.5.6 | Montaje tuberías y equipos auxiliares | 33.33d | 2002-11-14 | 2003-01-03 | 45, 15, 25 |  |  | 2002-10-16 | 2002-12-12 | 40d | 0d |  | Montadores tuberias [1300%]; Mont tub bis [200%] | 4000h |  | 16,266,666.19 | 16,000,000 |  |
| 47 | 1.5.7 | Montaje electricidad e instrumentación | 33.09d | 2003-01-03 | 2003-02-21 | 30, 35, 46 |  |  | 2002-12-13 | 2003-02-11 | 40d | 0d |  | Montadores elect e inst [1500%]; Mont elect bis [200%] | 4500h |  | 18,264,705.88 | 18,000,000 |  |
| 48 | 1.6 | **PRUEBAS Y PUESTA EN SERVICIO** | 88.09d | 2003-01-03 | 2003-05-15 |  |  |  | 2002-12-13 | 2003-05-05 | 95d | 0d |  |  | 6770h |  | 49,985,000 | 49,985,000 |  |
| 49 | 1.6.1 | Pruebas equipos en vacío | 15d | 2003-02-03 | 2003-02-24 | 50, 45 |  |  | 2003-01-15 | 2003-02-04 | 15d | 13.09d |  | Consumos pruebas equipos; Operarios [625%] | 870h |  | 4,995,000 | 4,995,000 |  |
| 50 | 1.6.2 | Pruebas hidraúlicas tuberías y equipos | 20d | 2003-01-03 | 2003-02-03 | 46 |  |  | 2002-12-13 | 2003-01-14 | 20d | 13.09d | 0d | Consumos pruebas hidraulicas; Operarios [937.5%] | 1660h |  | 10,000,000 | 10,000,000 |  |
| 51 | 1.6.3 | Pruebas eléctricas | 15d | 2003-02-21 | 2003-03-14 | 47 |  |  | 2003-02-12 | 2003-03-04 | 15d | 0d |  | Consumos prubas electricas; Operarios [625%] | 870h |  | 4,995,000 | 4,995,000 |  |
| 52 | 1.6.4 | Pruebas instrumentos y sist control | 15d | 2003-02-21 | 2003-03-14 | 47 |  |  | 2003-02-12 | 2003-03-04 | 15d | 0d |  | Consumos pruebas instrumentación; Operarios [625%] | 870h |  | 4,995,000 | 4,995,000 |  |
| 53 | 1.6.5 | Puesta en marcha | 20d | 2003-03-14 | 2003-04-16 | 49, 51, 52 |  |  | 2003-03-05 | 2003-04-04 | 20d | 0d |  | Personal de operación [625%] | 1000h |  | 10,000,000 | 10,000,000 |  |
| 54 | 1.6.6 | Puesta en operación | 10d | 2003-04-16 | 2003-04-30 | 53 |  |  | 2003-04-07 | 2003-04-18 | 10d | 0d |  | Personal de operación [875%] | 700h |  | 7,000,000 | 7,000,000 |  |
| 55 | 1.6.7 | Garantías y recepción | 10d | 2003-04-30 | 2003-05-15 | 54, 44 |  |  | 2003-04-21 | 2003-05-05 | 10d | 0d |  | Personal de operación [1000%] | 800h |  | 8,000,000 | 8,000,000 |  |
